# Malware Protection Overhaul

Schedule from MS Project, 2012-11-05 to 2012-12-05, A marks actual dates.
MIT

## Calendars

- Standard: Mon-Fri 08:00-12:00, 13:00-17:00; Sat-Sun off.

## Resources

| Resource |
| --- |
| Andrew |
| Sophie |
| Richard |
| Tim |

## Schedule

| ID | WBS | Task | Type | Duration | Start | Finish | Complete | Remaining | Total slack | Resources | Work | Actual work |
| --- | --- | --- | --- | --- | --- | --- | --- | --- | --- | --- | --- | --- |
| 1 | 1 | **Malware Protection Overhaul Project** |  | 23d? | 2012-11-05 A | 2012-12-05 | 20% | 18.32d? | 0d |  | 104h | 72.8h |
| 2 | 1.1 | **Planning** |  | 1d | 2012-11-05 A | 2012-11-05 A | 100% |  |  |  | 24h | 24h |
| 3 | 1.1.1 | Define scope | manual | 1d | 2012-11-05 A | 2012-11-05 A | 100% |  |  | Sophie | 8h | 8h |
| 4 | 1.1.2 | Review scope with Mark | manual | 1d | 2012-11-05 A | 2012-11-05 A | 100% |  |  | Sophie | 8h | 8h |
| 5 | 1.1.3 | Kickoff Meeting - include other teams | manual | 1d | 2012-11-05 A | 2012-11-05 A | 100% |  |  | Sophie | 8h | 8h |
| 6 | 1.2 | **Communications** |  | 1d? | 2012-11-14 A | 2012-11-14 | 83% | 0.17d? | 0d |  | 24h | 20h |
| 7 | 1.2.1 | Initial IT Leader meeting presentation |  | 1d? | 2012-11-14 A | 2012-11-14 A | 100% |  |  | Andrew | 8h | 8h |
| 8 | 1.2.2 | Contact IT Leaders to solicite volunteers for pilot | manual | 1d? | 2012-11-14 A | 2012-11-14 | 50% | 0.5d? |  | Tim | 8h | 4h |
| 9 | 1.2.3 | Checklist for pilot | manual | 1d | 2012-11-14 A | 2012-11-14 A | 100% |  |  | Andrew | 8h | 8h |
| 10 | 1.3 | **Windows Selection** |  | 1d? | 2012-11-14 A | 2012-11-14 | 14% | 0.86d? | 0d |  | 40h | 17.6h |
| 11 | 1.3.1 | **System Center 2012 (Forefront) Evaluation** |  | 1d? | 2012-11-14 A | 2012-11-14 | 20% | 0.8d? | 0d | Andrew | 24h | 9.6h |
| 12 | 1.3.1.1 | VM setup | manual | 1d | 2012-11-14 A | 2012-11-14 A | 100% |  |  | Richard | 8h | 8h |
| 13 | 1.3.1.2 | Console setup | manual | 1d? | 2012-11-14 | 2012-11-14 |  |  |  | Richard | 8h |  |
| 14 | 1.3.1.3 | Console and client functionality evaluation | manual | 1d? | 2012-11-14 | 2012-11-14 |  |  |  |  |  |  |
| 15 | 1.3.1.4 | Document pros and cons | manual | 1d? | 2012-11-14 | 2012-11-14 |  |  |  |  |  |  |
| 16 | 1.3.1.5 | Go/No Go? | manual | 1d? | 2012-11-14 | 2012-11-14 |  |  |  |  |  |  |
| 17 | 1.3.2 | **ESET Evaluation (v5.0 - Jan 2013)** |  | 1d? | 2012-11-14 A | 2012-11-14 | 60% | 0.4d? | 0d | Andrew | 8h |  |
| 18 | 1.3.2.1 | VM setup | manual | 1d | 2012-11-14 A | 2012-11-14 A | 100% |  |  |  |  |  |
| 19 | 1.3.2.2 | Console setup | manual | 1d | 2012-11-14 A | 2012-11-14 A | 100% |  |  |  |  |  |
| 20 | 1.3.2.3 | Console and client functionality evaluation | manual | 1d | 2012-11-14 A | 2012-11-14 A | 100% |  |  |  |  |  |
| 21 | 1.3.2.4 | Document pros and cons | manual | 1d? | 2012-11-14 | 2012-11-14 |  |  |  |  |  |  |
| 22 | 1.3.2.5 | Go/No Go? | manual | 1d? | 2012-11-14 | 2012-11-14 |  |  |  |  |  |  |
| 23 | 1.3.3 | **Vendor Demo** |  | 1d? | 2012-11-14 | 2012-11-14 |  |  | 0d |  |  |  |
| 24 | 1.3.3.1 | Determine invitees | manual | 1d? | 2012-11-14 | 2012-11-14 |  |  |  |  |  |  |
| 25 | 1.3.3.2 | Determine requirements | manual | 1d? | 2012-11-14 | 2012-11-14 |  |  |  |  |  |  |
| 26 | 1.3.3.3 | Demo | manual | 1d? | 2012-11-14 | 2012-11-14 |  |  |  |  |  |  |
| 27 | 1.3.3.4 | Team feedback | manual | 1d? | 2012-11-14 | 2012-11-14 |  |  |  |  |  |  |
| 28 | 1.3.3.5 | Go/No Go? | manual | 1d? | 2012-11-14 | 2012-11-14 |  |  |  |  |  |  |

| ID | WBS | Task | Type | Duration | Start | Finish | Complete | Remaining | Total slack | Resources | Work | Actual work |
| --- | --- | --- | --- | --- | --- | --- | --- | --- | --- | --- | --- | --- |
| 29 | 1.3.4 | **Analyze Recommendation and Solution** |  | 1d? | 2012-11-14 A | 2012-11-14 | 20% | 0.8d? | 0d |  | 8h | 8h |
| 30 | 1.3.4.1 | Peer school comparion breakdown | manual | 1d | 2012-11-14 A | 2012-11-14 A | 100% |  |  | Andrew | 8h | 8h |
| 31 | 1.3.4.2 | Determine any contract/licensing issues | manual | 1d | 2012-11-14 | 2012-11-14 |  |  |  |  |  |  |
| 32 | 1.3.4.3 | Determine total cost of ownership | manual | 1d? | 2012-11-14 | 2012-11-14 |  |  |  |  |  |  |
| 33 | 1.3.4.4 | Determine benefits and concerns | manual | 1d? | 2012-11-14 | 2012-11-14 |  |  |  |  |  |  |
| 34 | 1.3.4.5 | Determine support process/structure | manual | 1d? | 2012-11-14 | 2012-11-14 |  |  |  |  |  |  |
| 35 | 1.3.5 | **Sponsor approval** |  | 1d? | 2012-11-14 | 2012-11-14 |  |  | 0d |  |  |  |
| 36 | 1.3.5.1 | Approval from sponsor | manual | 1d? | 2012-11-14 | 2012-11-14 |  |  |  |  |  |  |
| 37 | 1.3.6 | **McAfee License** |  | 1d? | 2012-11-14 A | 2012-11-14 | 50% | 0.5d? | 0d |  |  |  |
| 38 | 1.3.6.1 | Understand current McAfee license constraints | manual | 1d | 2012-11-14 A | 2012-11-14 A | 100% |  |  |  |  |  |
| 39 | 1.3.6.2 | Adjust McAfee license based on new requirements | manual | 1d? | 2012-11-14 | 2012-11-14 |  |  |  |  |  |  |
| 40 | 1.3.7 | **Documentation and communication** |  | 1d? | 2012-11-14 | 2012-11-14 |  |  | 0d |  |  |  |
| 41 | 1.3.7.1 | Helpdesk (awareness only) | manual | 1d? | 2012-11-14 | 2012-11-14 |  |  |  |  |  |  |
| 42 | 1.3.7.2 | DITR (awareness only) | manual | 1d? | 2012-11-14 | 2012-11-14 |  |  |  |  |  |  |
| 43 | 1.3.7.3 | ITLEADERS (awareness and preparing for early adaptors only) | manual | 1d? | 2012-11-14 | 2012-11-14 |  |  |  |  |  |  |
| 44 | 1.3.8 | **Pilot rollout (STAKEHOLDERS)** |  | 1d? | 2012-11-14 | 2012-11-14 |  |  | 0d |  |  |  |
| 45 | 1.3.8.1 | Determine pilot rollout team | manual | 1d? | 2012-11-14 | 2012-11-14 |  |  |  |  |  |  |
| 46 | 1.3.8.2 | Determine timelines | manual | 1d? | 2012-11-14 | 2012-11-14 |  |  |  |  |  |  |
| 47 | 1.3.8.3 | determine pilot rollout strategy | manual | 1d? | 2012-11-14 | 2012-11-14 |  |  |  |  |  |  |
| 48 | 1.3.8.4 | Collect feedback | manual | 1d? | 2012-11-14 | 2012-11-14 |  |  |  |  |  |  |
| 49 | 1.3.8.5 | Checkpoint: Present pilot rollout feedback to Sponsor | manual | 1d? | 2012-11-14 | 2012-11-14 |  |  |  |  |  |  |
| 50 | 1.3.9 | **Procurement** |  | 1d? | 2012-11-14 | 2012-11-14 |  |  | 0d |  |  |  |
| 51 | 1.3.9.1 | Negotiate pricing | manual | 1d? | 2012-11-14 | 2012-11-14 |  |  |  |  |  |  |
| 52 | 1.3.9.2 | Contract agreement and signature | manual | 1d? | 2012-11-14 | 2012-11-14 |  |  |  |  |  |  |
| 53 | 1.3.9.3 | Purchase | manual | 1d? | 2012-11-14 | 2012-11-14 |  |  |  |  |  |  |
| 54 | 1.3.9.4 | Reminder: adjust McAfee contract | manual | 1d? | 2012-11-14 | 2012-11-14 |  |  |  |  |  |  |

| ID | WBS | Task | Type | Duration | Start | Finish | Complete | Remaining | Total slack | Resources | Work | Actual work |
| --- | --- | --- | --- | --- | --- | --- | --- | --- | --- | --- | --- | --- |
| 55 | 1.3.10 | **EARLY ADOPTERS** |  | 1d? | 2012-11-14 | 2012-11-14 |  |  | 0d |  |  |  |
| 56 | 1.3.10.1 | Determine early adopters participants | manual | 1d? | 2012-11-14 | 2012-11-14 |  |  |  |  |  |  |
| 57 | 1.3.10.2 | Determine timelines | manual | 1d? | 2012-11-14 | 2012-11-14 |  |  |  |  |  |  |
| 58 | 1.3.10.3 | determine beta rollout strategy | manual | 1d? | 2012-11-14 | 2012-11-14 |  |  |  |  |  |  |
| 59 | 1.3.10.4 | collect feedback | manual | 1d? | 2012-11-14 | 2012-11-14 |  |  |  |  |  |  |
| 60 | 1.3.11 | Final Checkpoint: Present all feedback including beta rollout feedback to Sponsor | manual | 1d? | 2012-11-14 | 2012-11-14 |  |  |  |  |  |  |
| 61 | 1.3.12 | **General Communications** |  | 1d? | 2012-11-14 | 2012-11-14 |  |  | 0d |  |  |  |
| 62 | 1.3.12.1 | to community | manual | 1d? | 2012-11-14 | 2012-11-14 |  |  |  |  |  |  |
| 63 | 1.3.13 | **Prep Helpdesk for full rollout support** |  | 1d? | 2012-11-14 | 2012-11-14 |  |  | 0d |  |  |  |
| 64 | 1.3.13.1 | any additional training/documentation | manual | 1d? | 2012-11-14 | 2012-11-14 |  |  |  |  |  |  |
| 65 | 1.3.14 | **Full rollout (COMMUNITY)** |  | 1d? | 2012-11-14 | 2012-11-14 |  |  | 0d |  |  |  |
| 66 | 1.3.14.1 | Provide software to SWRT for distribution | manual | 1d? | 2012-11-14 | 2012-11-14 |  |  |  |  |  |  |
| 67 | 1.4 | **MAC Selection** |  | 16d? | 2012-11-14 A | 2012-12-05 | 17% | 13.27d? | 0d |  | 16h | 11.2h |
| 68 | 1.4.1 | **Evaluation** |  | 6d? | 2012-11-28 A | 2012-12-05 | 70% | 1.8d? | 0d |  | 16h | 11.2h |
| 69 | 1.4.1.1 | **Sophos Evaluation** |  | 6d? | 2012-11-28 A | 2012-12-05 | 80% | 1.2d? | 0d | Andrew | 8h | 6.4h |
| 70 | 1.4.1.1.1 | VM setup | manual | 1d | 2012-11-28 A | 2012-11-28 A | 100% |  |  |  |  |  |
| 71 | 1.4.1.1.2 | Console setup | manual | 1d | 2012-12-05 A | 2012-12-05 A | 100% |  |  |  |  |  |
| 72 | 1.4.1.1.3 | Console and client functionality evaluation | manual | 1d | 2012-11-28 A | 2012-11-28 A | 100% |  |  |  |  |  |
| 73 | 1.4.1.1.4 | Document Pros and cons | manual | 1d? | 2012-11-28 | 2012-11-28 |  |  |  |  |  |  |
| 74 | 1.4.1.1.5 | Go/No Go? | manual | 1d | 2012-11-28 A | 2012-11-28 A | 100% |  |  |  |  |  |
| 75 | 1.4.1.2 | **ESET Evaluation (v5.0 - Jan 2013)** |  | 1d? | 2012-12-05 A | 2012-12-05 | 60% | 0.4d? | 0d | Andrew | 8h | 4.8h |
| 76 | 1.4.1.2.1 | VM setup | manual | 1d | 2012-12-05 A | 2012-12-05 A | 100% |  |  |  |  |  |
| 77 | 1.4.1.2.2 | Console setup | manual | 1d | 2012-12-05 A | 2012-12-05 A | 100% |  |  |  |  |  |
| 78 | 1.4.1.2.3 | Console and client functionality evaluation | manual | 1d | 2012-12-05 A | 2012-12-05 A | 100% |  |  |  |  |  |
| 79 | 1.4.1.2.4 | Document pros and cons | manual | 1d? | 2012-12-05 | 2012-12-05 |  |  |  |  |  |  |
| 80 | 1.4.1.2.5 | Go/No Go? | manual | 1d? | 2012-12-05 | 2012-12-05 |  |  |  |  |  |  |

| ID | WBS | Task | Type | Duration | Start | Finish | Total slack |
| --- | --- | --- | --- | --- | --- | --- | --- |
| 81 | 1.4.2 | **Vendor Demo** |  | 1d? | 2012-11-14 | 2012-11-14 | 0d |
| 82 | 1.4.2.1 | Determine which vendor(s) to demo | manual | 1d? | 2012-11-14 | 2012-11-14 |  |
| 83 | 1.4.2.2 | Determine invitees | manual | 1d? | 2012-11-14 | 2012-11-14 |  |
| 84 | 1.4.2.3 | Determine requirements | manual | 1d? | 2012-11-14 | 2012-11-14 |  |
| 85 | 1.4.2.4 | Demo | manual | 1d? | 2012-11-14 | 2012-11-14 |  |
| 86 | 1.4.2.5 | Team feedback | manual | 1d? | 2012-11-14 | 2012-11-14 |  |
| 87 | 1.4.2.6 | Checkpoint: Team Evaluation success? | manual | 1d? | 2012-11-14 | 2012-11-14 |  |
| 88 | 1.4.3 | **Analyze Recommendation and Solution** |  | 1d? | 2012-11-14 | 2012-11-14 | 0d |
| 89 | 1.4.3.1 | Determine any contract/licensing issues | manual | 1d? | 2012-11-14 | 2012-11-14 |  |
| 90 | 1.4.3.2 | Determine total cost of ownership | manual | 1d? | 2012-11-14 | 2012-11-14 |  |
| 91 | 1.4.3.3 | Determine benefits and concerns | manual | 1d? | 2012-11-14 | 2012-11-14 |  |
| 92 | 1.4.3.4 | Determine support process/structure | manual | 1d? | 2012-11-14 | 2012-11-14 |  |
| 93 | 1.4.4 | **Sponsor approval** |  | 1d? | 2012-11-14 | 2012-11-14 | 0d |
| 94 | 1.4.4.1 | Approval from sponsor | manual | 1d? | 2012-11-14 | 2012-11-14 |  |
| 95 | 1.4.5 | **Documentation and communication** |  | 1d? | 2012-11-14 | 2012-11-14 | 0d |
| 96 | 1.4.5.1 | Helpdesk (awareness only) | manual | 1d? | 2012-11-14 | 2012-11-14 |  |
| 97 | 1.4.5.2 | DITR (awareness only) | manual | 1d? | 2012-11-14 | 2012-11-14 |  |
| 98 | 1.4.5.3 | ITLEADERS (awareness and preparing for early adaptors only) | manual | 1d? | 2012-11-14 | 2012-11-14 |  |
| 99 | 1.4.6 | **Pilot rollout (STAKEHOLDERS)** |  | 1d? | 2012-11-14 | 2012-11-14 | 0d |
| 100 | 1.4.6.1 | Determine pilot rollout team | manual | 1d? | 2012-11-14 | 2012-11-14 |  |
| 101 | 1.4.6.2 | Determine timelines | manual | 1d? | 2012-11-14 | 2012-11-14 |  |
| 102 | 1.4.6.3 | determine pilot rollout strategy | manual | 1d? | 2012-11-14 | 2012-11-14 |  |
| 103 | 1.4.6.4 | Collect feedback | manual | 1d? | 2012-11-14 | 2012-11-14 |  |
| 104 | 1.4.6.5 | Checkpoint: Present pilot rollout feedback to Sponsor | manual | 1d? | 2012-11-14 | 2012-11-14 |  |

| ID | WBS | Task | Type | Duration | Start | Finish | Total slack |
| --- | --- | --- | --- | --- | --- | --- | --- |
| 105 | 1.4.7 | **Procurement** |  | 1d? | 2012-11-14 | 2012-11-14 | 0d |
| 106 | 1.4.7.1 | Negotiate pricing | manual | 1d? | 2012-11-14 | 2012-11-14 |  |
| 107 | 1.4.7.2 | Contract agreement and signature | manual | 1d? | 2012-11-14 | 2012-11-14 |  |
| 108 | 1.4.7.3 | Purchase | manual | 1d? | 2012-11-14 | 2012-11-14 |  |
| 109 | 1.4.7.4 | Reminder: adjust McAfee contract | manual | 1d? | 2012-11-14 | 2012-11-14 |  |
| 110 | 1.4.8 | **EARLY ADOPTERS** |  | 1d? | 2012-11-14 | 2012-11-14 | 0d |
| 111 | 1.4.8.1 | Determine early adopters participants | manual | 1d? | 2012-11-14 | 2012-11-14 |  |
| 112 | 1.4.8.2 | Determine timelines | manual | 1d? | 2012-11-14 | 2012-11-14 |  |
| 113 | 1.4.8.3 | determine beta rollout strategy | manual | 1d? | 2012-11-14 | 2012-11-14 |  |
| 114 | 1.4.8.4 | collect feedback | manual | 1d? | 2012-11-14 | 2012-11-14 |  |
| 115 | 1.4.9 | Final Checkpoint: Present all feedback including beta rollout feedback to Sponsor | manual | 1d? | 2012-11-14 | 2012-11-14 |  |
| 116 | 1.4.10 | **General Communications** |  | 1d? | 2012-11-14 | 2012-11-14 | 0d |
| 117 | 1.4.10.1 | to community | manual | 1d? | 2012-11-14 | 2012-11-14 |  |
| 118 | 1.4.11 | **Prep Helpdesk for full rollout support** |  | 1d? | 2012-11-14 | 2012-11-14 | 0d |
| 119 | 1.4.11.1 | any additional training/documentation | manual | 1d? | 2012-11-14 | 2012-11-14 |  |
| 120 | 1.4.12 | **Full rollout (COMMUNITY)** |  | 1d? | 2012-11-14 | 2012-11-14 | 0d |
| 121 | 1.4.12.1 | Provide software to SWRT for distribution | manual | 1d? | 2012-11-14 | 2012-11-14 |  |
| 122 | 1.5 | **Project Wrapup** |  | 1d? | 2012-11-14 | 2012-11-14 | 0d |
| 123 | 1.5.1 | closeout project | manual | 1d? | 2012-11-14 | 2012-11-14 |  |
